# BIAUV 2008 Work Plan~890

Schedule from MS Project, 2008-10-23 to 2008-11-26, A marks actual dates.
MBARI

## Calendars

- Standard: Mon-Fri 08:00-12:00, 13:00-17:00; Sat-Sun off.

## Resources

| Resource |
| --- |
| Lance |
| Brett |
| Thomas |
| Machine shop |
| Jon |
| Lance McBride |
| Thomas Hoover |
| Test Tank |
| Rob Mcewen |
| Zephyr |
| Brett Hobson |
| Jon Erickson |
| AUV Fabricator #1 |
| Mike Godin |
| Yanwu Zhang |
| Rich |
| EE |
| SE |
| ME |
| MS |
| RE |
| ET |
| MT |
| SE ME |
| Alana |
| Jim S |
| AUV |
| Rob |
| Kent |
| Tom |
| Doug |

## Schedule

| ID | WBS | Task | Duration | Start | Finish | Predecessors | Complete | Remaining | Total slack | Free slack | Resources | Work | Actual work |
| --- | --- | --- | --- | --- | --- | --- | --- | --- | --- | --- | --- | --- | --- |
| 1 | 1 | **BIAUV 2008 Work Plan** | 25d? | 2008-10-23 A | 2008-11-26 |  | 26% | 18.46d? | 0d |  |  | 568h | 128h |
| 2 | 1.1 | Camera System | 1d? | 2008-10-23 | 2008-10-23 |  |  |  | 24d |  |  |  |  |
| 3 | 1.2 | **Camera** | 12.5d? | 2008-10-23 A | 2008-11-10 |  | 56% | 5.5d? | 12.5d |  |  | 112h | 56h |
| 4 | 1.2.1 | order12 vdc vicor power supplies - mid nov | 1d? | 2008-10-23 A | 2008-10-23 A |  | 100% |  |  |  | Alana | 8h | 8h |
| 5 | 1.2.2 | model housed components | 1d? | 2008-10-24 A | 2008-10-24 A | 4 | 100% |  |  |  | Jon | 8h | 8h |
| 6 | 1.2.3 | Lock down position of camera/lens | 1d? | 2008-10-27 A | 2008-10-27 A | 5 | 100% |  |  |  | Brett | 8h | 8h |
| 7 | 1.2.4 | design ball mounts | 1d? | 2008-10-28 A | 2008-10-28 A | 6 | 100% |  |  |  | Jon | 8h | 8h |
| 8 | 1.2.5 | build GPIO adaptor board | 1d? | 2008-10-29 A | 2008-10-29 A | 7 | 100% |  |  |  | Alana | 8h | 8h |
| 9 | 1.2.6 | fabricate ball mounts | 1d? | 2008-10-30 | 2008-10-30 | 8 |  |  | 11d | 0d | MS | 8h |  |
| 10 | 1.2.7 | mount xport, usb-ethernet, Eth switch, power supplies | 1d? | 2008-10-31 A | 2008-10-31 A | 9 | 100% |  |  |  | Brett | 8h | 8h |
| 11 | 1.2.8 | pressure test ball to 900m | 1d? | 2008-11-03 A | 2008-11-03 A | 10 | 100% |  |  |  | Brett | 8h | 8h |
| 12 | 1.2.9 | glue down camera bracket | 1d? | 2008-11-04 | 2008-11-04 | 11 |  |  | 11.5d | 0d | Jim S | 8h |  |
| 13 | 1.2.10 | tank test open sphere with camera and target | 1d? | 2008-11-05 | 2008-11-05 | 12 |  |  | 11.5d | 0d | Brett | 8h |  |
| 14 | 1.2.11 | Build up camera sphere | 1d? | 2008-11-06 | 2008-11-06 | 13 |  |  | 11d | 0d | Brett; Jon | 16h |  |
| 15 | 1.2.12 | Wire up | 0.5d? | 2008-11-07 | 2008-11-07 | 14 |  |  | 11.5d | 0d | Alana; Tom | 8h |  |
| 16 | 1.2.13 | Test | 1d? | 2008-11-07 | 2008-11-10 | 82, 15 |  |  | 11.5d | 0d | Alana | 8h |  |
| 17 | 1.3 | **Strobe** | 4d? | 2008-10-23 A | 2008-10-28 |  | 25% | 3d? | 21d |  |  | 32h | 8h |
| 18 | 1.3.1 | Order (2) AquaStrobes | 1d? | 2008-10-23 A | 2008-10-23 A |  | 100% |  |  |  | Brett | 8h | 8h |
| 19 | 1.3.2 | Modify mounts to hold reflector | 1d? | 2008-10-24 | 2008-10-24 | 18 |  |  | 21d | 0d | Jon | 8h |  |
| 20 | 1.3.3 | order wet cabling | 1d? | 2008-10-27 | 2008-10-27 | 19 |  |  | 21d | 0d | Alana | 8h |  |
| 21 | 1.3.4 | build wet cabling | 1d? | 2008-10-28 | 2008-10-28 | 20 |  |  | 21d |  | Alana | 8h |  |
| 22 | 1.4 | **AUV Systems** | 10d? | 2008-10-23 A | 2008-11-05 |  | 25% | 7.5d? | 15d |  |  | 224h | 40h |
| 23 | 1.4.1 | **Nose Section** | 9d? | 2008-10-23 A | 2008-11-04 |  | 11% | 8d? | 16d |  |  | 72h | 8h |
| 24 | 1.4.1.1 | Fabricate bulkheads, USBL and OAS mounts | 1d? | 2008-10-23 | 2008-10-23 |  |  |  | 9d | 0d | MS | 8h |  |
| 25 | 1.4.1.2 | Fabricate strobe mount | 1d? | 2008-10-24 | 2008-10-24 | 24 |  |  | 9d | 0d | MS | 8h |  |
| 26 | 1.4.1.3 | Fabricate tow hook parts | 1d? | 2008-10-27 A | 2008-10-27 A | 25 | 100% |  |  |  | Doug | 8h | 8h |
| 27 | 1.4.1.4 | add holes to nose skin bulkhead ring | 1d? | 2008-10-28 | 2008-10-28 | 26 |  |  | 9d | 0d | MT | 8h |  |
| 28 | 1.4.1.5 | cut hole for tow bar | 1d? | 2008-10-29 | 2008-10-29 | 27 |  |  | 9d | 0d | Jim S | 8h |  |
| 29 | 1.4.1.6 | cut hole for strobe | 1d? | 2008-10-30 | 2008-10-30 | 28 |  |  | 9d | 0d | Jim S | 8h |  |
| 30 | 1.4.1.7 | build and install transparent hole cover | 1d? | 2008-10-31 | 2008-10-31 | 29 |  |  | 9d | 0d | Jim S | 8h |  |
| 31 | 1.4.1.8 | install foam sections | 1d? | 2008-11-03 | 2008-11-03 | 30 |  |  | 9d | 0d | Jim S | 8h |  |
| 32 | 1.4.1.9 | Assemble components: USBL, OAS, strobe | 1d? | 2008-11-04 | 2008-11-04 | 31 |  |  | 9d | 1d | Jim S | 8h |  |

| ID | WBS | Task | Duration | Start | Finish | Predecessors | Complete | Remaining | Total slack | Free slack | Resources | Work | Actual work |
| --- | --- | --- | --- | --- | --- | --- | --- | --- | --- | --- | --- | --- | --- |
| 33 | 1.4.2 | **66" section** | 10d? | 2008-10-23 A | 2008-11-05 |  | 44% | 5.56d? | 15d |  |  | 72h | 24h |
| 34 | 1.4.2.1 | Design sphere mount | 1d? | 2008-10-23 A | 2008-10-23 A |  | 100% |  |  |  | Jon | 8h | 8h |
| 35 | 1.4.2.2 | fabricate sphere mount | 1d? | 2008-10-24 | 2008-10-24 | 34 |  |  | 8d | 0d | Jon | 8h |  |
| 36 | 1.4.2.3 | install sphere mounting bulkheads and sphere | 1d? | 2008-10-27 | 2008-10-27 | 35 |  |  | 22d |  | Jim S | 8h |  |
| 37 | 1.4.2.4 | Design DVL mount | 1d? | 2008-10-29 A | 2008-10-29 A | 36 | 100% |  |  |  | Jon | 8h | 8h |
| 38 | 1.4.2.5 | fabricate DVL mount | 1d? | 2008-10-30 | 2008-10-30 | 37 |  |  | 17d | 0d | MS | 8h |  |
| 39 | 1.4.2.6 | Build up battery J-box | 1d? | 2008-10-31 A | 2008-10-31 A | 38 | 100% |  |  |  |  |  |  |
| 40 | 1.4.2.7 | cut hole in bottom skin for camera FOV | 1d? | 2008-11-03 | 2008-11-03 | 39 |  |  | 17d |  | Jim S | 8h |  |
| 41 | 1.4.2.8 | install 3 batteries | 1d? | 2008-11-04 A | 2008-11-04 A | 40 | 100% |  |  |  | AUV | 8h | 8h |
| 42 | 1.4.2.9 | Assemble components | 1d? | 2008-11-05 | 2008-11-05 | 41 |  |  | 8d | 0d | Jim S; AUV | 16h |  |
| 43 | 1.4.3 | **Tail section** | 7d? | 2008-10-23 A | 2008-10-31 |  | 21% | 5.5d? | 18d |  |  | 80h | 8h |
| 44 | 1.4.3.1 | install tail cone | 1d? | 2008-10-23 | 2008-10-23 |  |  |  | 19d | 0d | AUV | 8h |  |
| 45 | 1.4.3.2 | mount strobe | 1d? | 2008-10-24 | 2008-10-24 | 44 |  |  | 19d | 0d |  |  |  |
| 46 | 1.4.3.3 | cut strobe hole | 1d? | 2008-10-27 | 2008-10-27 | 45 |  |  | 19d | 0d | Jim S | 8h |  |
| 47 | 1.4.3.4 | fabricate and install transparent cover | 1d? | 2008-10-28 | 2008-10-28 | 46 |  |  | 19d | 0d | Jim S | 8h |  |
| 48 | 1.4.3.5 | install aft strobe assembly | 1d? | 2008-10-29 | 2008-10-29 | 47 |  |  | 19d | 0d | Jim S | 8h |  |
| 49 | 1.4.3.6 | install SSM and Homer | 1d? | 2008-10-30 | 2008-10-30 | 48 |  |  | 19d |  | AUV | 8h |  |
| 50 | 1.4.3.7 | install drop weight | 1d? | 2008-10-31 A | 2008-10-31 A | 49 | 100% |  |  |  | AUV | 8h | 8h |
| 51 | 1.4.3.8 | **MVC** | 3d? | 2008-10-23 | 2008-10-27 |  |  |  | 22d |  |  | 24h |  |
| 52 | 1.4.3.8.1 | **WiFi** | 3d? | 2008-10-23 | 2008-10-27 |  |  |  | 22d |  |  | 24h |  |
| 53 | 1.4.3.8.1.1 | specify and order WiFi | 1d? | 2008-10-23 | 2008-10-23 |  |  |  | 22d | 0d | Alana | 8h |  |
| 54 | 1.4.3.8.1.2 | install and configure WiFi | 1d? | 2008-10-24 | 2008-10-24 | 53 |  |  | 22d | 0d | Alana | 8h |  |
| 55 | 1.4.3.8.1.3 | build WiFi antenna and mold to cable | 1d? | 2008-10-27 | 2008-10-27 | 54 |  |  | 22d |  | Jim S | 8h |  |
| 56 | 1.4.3.9 | order MicroStrain AHRS | 1d? | 2008-10-23 A | 2008-10-23 A |  | 100% |  |  |  |  |  |  |
| 57 | 1.4.3.10 | Install AHRS | 1d? | 2008-10-23 | 2008-10-23 |  |  |  | 24d |  |  |  |  |
| 58 | 1.4.3.11 | install hard drive | 1d? | 2008-10-23 A | 2008-10-23 A |  | 100% |  |  |  |  |  |  |
| 59 | 1.4.3.12 | seal up sphere | 1d? | 2008-10-23 | 2008-10-23 |  |  |  | 24d |  | AUV | 8h |  |

| ID | WBS | Task | Duration | Start | Finish | Predecessors | Complete | Remaining | Total slack | Free slack | Constraint | Resources | Work | Actual work |
| --- | --- | --- | --- | --- | --- | --- | --- | --- | --- | --- | --- | --- | --- | --- |
| 60 | 1.5 | **Navigation and Control** | 13.5d? | 2008-10-23 A | 2008-11-11 |  | 33% | 9d? | 11.5d |  |  |  | 32h | 16h |
| 61 | 1.5.1 | confirm computer boots and runs under old QNX | 1d? | 2008-10-23 A | 2008-10-23 A |  | 100% |  |  |  |  | AUV; Rob | 16h | 16h |
| 62 | 1.5.2 | Confirm USBL still works | 1d? | 2008-10-24 | 2008-10-24 | 61 |  |  | 22d | 10.5d |  | Rob | 8h |  |
| 63 | 1.5.3 | run sim with camera - confirm it fires | 1d? | 2008-11-10 | 2008-11-11 | 62, 16 |  |  | 11.5d |  |  | Rob | 8h |  |
| 64 | 1.6 | **Software** | 4d? | 2008-10-23 A | 2008-10-28 |  | 40% | 2.4d? | 19d |  |  |  | 24h | 8h |
| 65 | 1.6.1 | Confirm X-port has AUV subnet IP | 1d? | 2008-10-23 A | 2008-10-23 A |  | 100% |  |  |  |  |  |  |  |
| 66 | 1.6.2 | run sim and confirm camera fires | 1d? | 2008-10-23 | 2008-10-23 |  |  |  | 22d | 0d |  | Rob | 8h |  |
| 67 | 1.6.3 | develop routine to update psudo GPS at 1 HZ | 1d? | 2008-10-24 A | 2008-10-24 A | 66 | 100% |  |  |  |  | Kent | 8h | 8h |
| 68 | 1.6.4 | Bench test | 1d? | 2008-10-27 | 2008-10-27 | 67 |  |  | 14d | 0d |  |  |  |  |
| 69 | 1.6.5 | test in AUV | 1d? | 2008-10-28 | 2008-10-28 | 68 |  |  | 14d | 6d |  | Rob | 8h |  |
| 70 | 1.7 | **test and integration** | 14d? | 2008-10-23 | 2008-11-11 |  |  |  | 11d |  |  |  | 72h |  |
| 71 | 1.7.1 | test fire camera and measure latency and precision of timing | 1d? | 2008-10-24 | 2008-10-24 | 66 |  |  | 22d | 0d |  | Kent; Rob | 16h |  |
| 72 | 1.7.2 | check GPS metadata time stamp | 1d? | 2008-10-27 | 2008-10-27 | 71 |  |  | 22d |  |  | Kent | 8h |  |
| 73 | 1.7.3 | **tank tests** | 14d? | 2008-10-23 | 2008-11-11 |  |  |  | 11d |  |  |  | 48h |  |
| 74 | 1.7.3.1 | build frame to hole camera sphere and two strobes | 1d? | 2008-10-23 | 2008-10-23 |  |  |  | 24d |  |  |  |  |  |
| 75 | 1.7.3.2 | trim vehicle to 6-8 lbs positive | 1d? | 2008-11-06 | 2008-11-06 | 69, 50, 42, 32 |  |  | 8d | 0d |  | Brett; AUV | 16h |  |
| 76 | 1.7.3.3 | build up 3m ballast bag hangers | 1d? | 2008-11-07 | 2008-11-07 | 75 |  |  | 8d | 0d |  | Jim S | 8h |  |
| 77 | 1.7.3.4 | run vehicle on test cable to tune camera and strobes | 1d? | 2008-11-10 | 2008-11-10 | 76 |  |  | 8d | 0d |  | Brett; Rob | 16h |  |
| 78 | 1.7.3.5 | upload images over WiFi | 1d? | 2008-11-11 | 2008-11-11 | 77 |  |  | 8d |  |  | Brett | 8h |  |
| 79 | 1.8 | **ocean tests** | 25d? | 2008-10-23 A | 2008-11-26 |  | 11% | 22.22d? | 0d |  |  |  | 72h |  |
| 80 | 1.8.1 | pressure test sphere | 1d? | 2008-10-23 A | 2008-10-23 A |  | 100% |  |  |  |  |  |  |  |
| 81 | 1.8.2 | **ROV tests** | 22d? | 2008-10-23 | 2008-11-21 |  |  |  | 0d |  |  |  | 40h |  |
| 82 | 1.8.2.1 | build up 110AC/24 vdc PS | 1d? | 2008-10-23 | 2008-10-23 |  |  |  | 18d | 0d |  | Alana | 8h |  |
| 83 | 1.8.2.2 | fabricate brackets | 1d? | 2008-10-24 | 2008-10-24 | 82 |  |  | 18d | 0d |  | Jon | 8h |  |
| 84 | 1.8.2.3 | dock tests | 1d? | 2008-10-27 | 2008-10-27 | 83 |  |  | 18d |  |  | Brett; Alana | 16h |  |
| 85 | 1.8.2.4 | ocean test | 1d? | 2008-11-21 | 2008-11-21 | 84 |  |  | 0d |  | start no earlier than 2008-11-21 | Brett | 8h |  |

| ID | WBS | Task | Duration | Start | Finish | Predecessors | Total slack | Resources | Work |
| --- | --- | --- | --- | --- | --- | --- | --- | --- | --- |
| 86 | 1.8.3 | **AUV tests** | 3d? | 2008-11-24 | 2008-11-26 | 85 | 0d |  | 32h |
| 87 | 1.8.3.1 | build up homer with float, anchor and surface float | 1d? | 2008-11-24 | 2008-11-24 | 78 | 0d | Brett | 8h |
| 88 | 1.8.3.2 | write mission to run star pattern around homer at 3m alt | 1d? | 2008-11-25 | 2008-11-25 | 87 | 0d | Rob | 8h |
| 89 | 1.8.3.3 | run mission, upload data, tweak camera settings | 1d? | 2008-11-26 | 2008-11-26 | 88 | 0d | Rob; Brett | 16h |
| 90 | 1.8.3.4 | Select site to collect "pretty" pictures | 1d? | 2008-11-24 | 2008-11-24 |  | 2d |  |  |
| 91 | 1.9 | **Data analysis** | 1d? | 2008-10-23 | 2008-10-23 |  | 24d |  |  |
| 92 | 1.9.1 | select images for mosaic and high res printing | 1d? | 2008-10-23 | 2008-10-23 |  | 24d |  |  |
| 93 | 1.9.2 | assemble mosaic | 1d? | 2008-10-23 | 2008-10-23 |  | 24d |  |  |
| 94 | 1.9.3 | print select images | 1d? | 2008-10-23 | 2008-10-23 |  | 24d |  |  |
